# Defensas ribereñas - Confluencia rio Casma

Schedule from Primavera P6, 2022-11-09 to 2023-06-21, data date 2022-11-09.

## Calendars

- DiasCalendario: Mon-Sun 08:00-16:00.

## Schedule

| ID | WBS | Activity | Duration | Start | Finish | Predecessors | Total float | Free float |
| --- | --- | --- | --- | --- | --- | --- | --- | --- |
|  | B | **CONSTRUCCION DE DEFENSAS RIBEREÑAS** |  | 2022-11-09 | 2023-06-21 |  |  |  |
|  | 100 | **OBRAS PROVISIONALES** |  | 2022-11-09 | 2022-12-10 |  |  |  |
| PROV01 |  | CARTEL DE IDENTIFICACION DE LA OBRA DE 3.60M X 2.40M. | 2d | 2022-11-09 | 2022-11-10 |  | 0d |  |
| PROV02 |  | INSTALACIÓN DE FACILIDADES Y CAMPAMENTOS | 30d | 2022-11-11 | 2022-12-10 | PROV01 | 18d | 0d |
|  | 200 | **OBRAS PRELIMINARES** |  | 2022-11-09 | 2023-06-09 |  |  |  |
| PRE01 |  | MOVILIZACIÓN Y DESMOVILIZACIÓN DE EQUIPOS Y/O MAQUINARIA | 15d | 2022-11-09 | 2022-11-23 | PROV01 SS | 29d | 0d |
| PRE02 |  | TRAZO, NIVELACION Y REPLANTEO PRELIMINAR | 30d | 2022-11-11 | 2022-12-10 | PROV01 | 0d |  |
| PRE03 |  | CONTROL TOPOGRAFICO DURANTE LA EJECUCIÓN | 180d | 2022-12-11 | 2023-06-08 | PRE02 | 13d |  |
| PRE04 |  | HABILITACIÓN DE ACCESOS | 21d | 2022-12-11 | 2022-12-31 | PRE02, PRE01 | 12d | 0d |
| PRE05 |  | DESVÍO Y MANEJO DE AGUAS SUPERFICIALES | 180d | 2022-12-11 | 2023-06-08 | PRE02 | 13d |  |
| PRE06 |  | MANTENIMIENTO DE TRÁNSITO Y SEG. VIAL EN ACCESOS A LA OBRA Y ÁREAS AUX. (Canteras, DME/DMO, Fuentes de agua) | 160d | 2023-01-01 | 2023-06-09 | PRE04 | 12d |  |
|  | 300 | **OPERACION Y EXPLOTACION DE MATERIAL** |  | 2022-12-11 | 2023-06-08 |  |  |  |
| EXP03 |  | PREPARACIÓN DE MATERIAL PARA CONFORMACIÓN DE DIQUE | 180d | 2022-12-11 | 2023-06-08 | PRE02, PRE01 | 13d | 0d |
| EXP02 |  | EXPLOTACION Y PREPARACION DE MATERIAL PARA AFIRMADO EN CORONA | 12d | 2023-05-28 | 2023-06-08 | PRE02, EXP03 FF | 13d |  |
|  | 400 | **MOVIMIENTO DE TIERRAS** |  | 2023-01-23 | 2023-06-21 |  |  |  |
|  | B1 | **CONSTRUCCION DE DIQUE NUEVO** |  | 2023-01-23 | 2023-06-21 |  |  |  |
| MTN12 |  | REFINE Y PERFILADO DE TALUD | 67d | 2023-01-23 | 2023-03-30 | MTN06 FF | 25d | 12d |
| MTN15 |  | GEOTEXTIL NO TEJIDO CLASE 1, INCLUYE INSTALACIÓN | 65d | 2023-01-25 | 2023-03-30 | MTN06 FF | 13d | 0d |
| MTN01 |  | DESBROCE Y LIMPIEZA | 23d | 2023-01-26 | 2023-02-17 | IVI15 SS, PRE02 | 0d |  |
| MTN02 |  | EXCAVACIÓN MASIVA EN MATERIAL SUELTO, CON EQUIPO | 55d | 2023-01-26 | 2023-03-21 | PRE02, MTN01 SS | 0d |  |
| MTN17 |  | CONFORMACIÓN DE DME/DMO | 120d | 2023-01-26 | 2023-05-25 | MTN01 SS | 27d |  |
| MTN05 |  | EXCAVACION DE UÑA EN MATERIAL CON NIVEL FREATICO | 60d | 2023-01-30 | 2023-03-30 | MTN04 FF | 0d |  |
| MTN06 |  | CONFORMACIÓN Y COMPACTACIÓN DE DIQUE | 60d | 2023-01-30 | 2023-03-30 | MTN05 SS | 13d | 0d |
| MTN13 |  | MEJORAMIENTO DE SUELO DE FUNDACIÓN | 19d | 2023-03-12 | 2023-03-30 | MTN05 FF | 83d |  |
| MTN21 |  | TRATAMIENTO DE TALUD CON GEOCELDAS (INCLUYE RELLENO DE GRAVAS) | 28d | 2023-03-15 | 2023-04-11 | MTN16 FF | 31d | 0d |
| MTN03 |  | EXCAVACIÓN EN ROCA SUELTA CON EQUIPO | 1d | 2023-03-22 | 2023-03-22 | MTN02 | 0d |  |
| MTN04 |  | EXCAVACION DE ROCA FIJA CON MARTILLO HIDRÁULICO | 8d | 2023-03-23 | 2023-03-30 | MTN03 | 0d |  |
| MTN09 |  | ENROCADO Y ACOMODO DE ROCA EN UÑA ANTISOCAVANTE TIPO 1 | 25d | 2023-03-31 | 2023-04-24 | MTN05, MTN16 FF | 0d |  |
| MTN11 |  | DESCOLMATACIÓN DEL CAUCE | 16d | 2023-03-31 | 2023-04-15 | MTN05, MTN01 | 67d |  |
| MTN16 |  | GEOTEXTIL NO TEJIDO CLASE 2, INCLUYE INSTALACIÓN | 12d | 2023-03-31 | 2023-04-11 | MTN15, MTN12 FF | 13d | 0d |
| MTN20 |  | RELLENO CON MATERIAL PROPIO | 47d | 2023-04-05 | 2023-05-21 | MTN19 FF | 31d |  |
| MTN14 |  | ZANJA Y RELLENO PARA ANCLAJE DE GEOTEXTIL | 23d | 2023-04-12 | 2023-05-04 | MTN21 | 31d | 0d |
| MTN10 |  | ENROCADO Y ACOMODO DE ROCA EN UÑA ANTISOCAVANTE TIPO 2 | 10d | 2023-04-25 | 2023-05-04 | MTN09 | 0d |  |
| MTN07 |  | ENROCADO Y ACOMODO DE ROCA PARA PROTECCIÓN DE TALUD TIPO 1 | 37d | 2023-05-05 | 2023-06-10 | MTN10 | 0d |  |
| MTN19 |  | RELLENO COMPACTADO CON MATERIAL PARA AFIRMADO EN CORONA | 17d | 2023-05-05 | 2023-05-21 | MTN14 | 31d | 0d |
| MTN08 |  | ENROCADO Y ACOMODO DE ROCA PARA PROTECCIÓN DE TALUD TIPO 2 | 11d | 2023-06-11 | 2023-06-21 | MTN07 | 0d |  |

| ID | WBS | Activity | Duration | Start | Finish | Predecessors | Total float | Free float |
| --- | --- | --- | --- | --- | --- | --- | --- | --- |
|  | B2 | **REFUERZO EN DIQUES EXISTENTES** |  | 2023-01-26 | 2023-05-28 |  |  |  |
| MTE01 |  | EXCAVACIÓN EN MATERIAL SUELTO, CON EQUIPO | 48d | 2023-01-26 | 2023-03-14 | MTN01 SS | 0d |  |
| MTE06 |  | ENROCADO Y ACOMODO DE ROCA EN TALUD DE DIQUE EXISTENTE | 60d | 2023-03-04 | 2023-05-02 | MTE07 FF | 0d |  |
| MTE07 |  | ENROCADO Y ACOMODO DE ROCA EN UÑA DE DIQUE EXISTENTE | 60d | 2023-03-04 | 2023-05-02 | MTE09 FF | 0d |  |
| MTE12 |  | GAVIÓN (INCLUYE INSTALACIÓN) | 60d | 2023-03-04 | 2023-05-02 | MTE10 FF, IRE01, IRE02 | 0d |  |
| MTE02 |  | EXCAVACIÓN EN ROCA SUELTA CON EQUIPO | 1d | 2023-03-15 | 2023-03-15 | MTE01 | 0d |  |
| MTE14 |  | RECUPERACIÓN DE ROCA EN DIQUES EXISTENTES | 75d | 2023-03-15 | 2023-05-28 | MTE01 | 24d |  |
| MTE03 |  | EXCAVACION DE UÑA EN MATERIAL CON NIVEL FREATICO | 46d | 2023-03-16 | 2023-04-30 | MTE02 | 0d |  |
| MTE10 |  | RELLENO COMPACTADO CON MATERIAL PARA AFIRMADO EN CORONA | 42d | 2023-03-22 | 2023-05-02 | MTE06 FF | 0d |  |
| MTE04 |  | CONFORMACIÓN Y COMPACTACIÓN DE DIQUE | 37d | 2023-03-25 | 2023-04-30 | MTE03 FF | 0d |  |
| MTE08 |  | GEOTEXTIL NO TEJIDO CLASE 1, INCLUYE INSTALACIÓN | 31d | 2023-03-31 | 2023-04-30 | MTE04 FF | 0d |  |
| MTE11 |  | RELLENO CON MATERIAL PROPIO | 30d | 2023-04-18 | 2023-05-17 | MTE13 FF | 10d | 0d |
| MTE05 |  | RECRECIMIENTO Y CONFORMACIÓN EN DIQUE EXISTENTE | 5d | 2023-04-28 | 2023-05-02 | MTE12 FF | 10d | 0d |
| MTE09 |  | GEOTEXTIL NO TEJIDO CLASE 2, INCLUYE INSTALACIÓN | 2d | 2023-05-01 | 2023-05-02 | MTE08 | 0d |  |
| MTE13 |  | PERFILADO Y COMPACTACIÓN DE CORONA EN DIQUE EXISTENTE | 15d | 2023-05-03 | 2023-05-17 | MTE05 | 10d | 0d |
|  | 500 | **TRANSPORTE DE MATERIAL** |  | 2022-11-24 | 2023-03-16 |  |  |  |
| TRA01 |  | CARGUIO Y ACARREO DE MATERIAL PROPIO D=1km | 15d | 2022-11-24 | 2022-12-08 | PRE01 | 191d | 0d |
| TRA03 |  | CARGUIO Y TRANSPORTE DE MATERIAL AFIRMADO D=1KM | 1d | 2022-11-24 | 2022-11-24 | PRE01 | 190d | 0d |
| TRA07 |  | CARGUIO Y TRANSPORTE DE MATERIAL EXCEDENTE CON EQUIPO D= 1km | 8d | 2022-11-24 | 2022-12-01 | PRE01 | 97d | 0d |
| TRA09 |  | CARGUIO Y TRANSPORTE DE ROCA SELECCIONADA D=1km | 7d | 2022-11-24 | 2022-11-30 | PRE01 | 138d | 0d |
| TRA10 |  | CARGUIO Y TRANSPORTE DE CANTOS RODADOS D=1km | 1d | 2022-11-24 | 2022-11-24 | PRE01 | 202d | 0d |
| TRA06 |  | TRANSPORTE DE MATERIAL AFIRMADO D>1KM | 19d | 2022-11-25 | 2022-12-13 | TRA03 | 190d |  |
| TRA12 |  | TRANSPORTE DE CANTOS RODADOS D >1km | 7d | 2022-11-25 | 2022-12-01 | TRA10 | 202d |  |
| TRA11 |  | TRANSPORTE DE ROCA SELECIONADA D >1km | 65d | 2022-12-01 | 2023-02-03 | TRA09 | 138d |  |
| TRA08 |  | TRANSPORTE DE MATERIAL EXCEDENTE CON EQUIPO D> 1km | 105d | 2022-12-02 | 2023-03-16 | TRA07 | 97d |  |
| TRA04 |  | ACARREO DE MATERIAL PROPIO D>1km | 4d | 2022-12-09 | 2022-12-12 | TRA01 | 191d |  |

| ID | WBS | Activity | Duration | Start | Finish | Predecessors | Total float | Free float |
| --- | --- | --- | --- | --- | --- | --- | --- | --- |
|  | 600 | **COMPONENTE DE INTERFERENCIAS** |  | 2022-12-11 | 2023-03-27 |  |  |  |
|  | C1 | **OBRAS DE RIEGO** |  | 2022-12-11 | 2023-02-11 |  |  |  |
| IRI01 |  | EXCAVACIÓN EN MATERIAL SUELTO, CON EQUIPO | 16d | 2022-12-11 | 2022-12-26 | PRE02, PRE01 | 130d | 0d |
| IRI03 |  | ENROCADO Y ACOMODO DE ROCA | 7d | 2022-12-11 | 2022-12-17 | PRE02 | 186d |  |
| IRI05 |  | REUBICACIÓN DE POZO PROFUNDO | 10d | 2022-12-11 | 2022-12-20 | PRE02 | 181d | 0d |
| IRI06 |  | EMBOQUILLADO DE PIEDRA CON CONCRETO | 45d | 2022-12-11 | 2023-01-24 | PRE02 | 137d | 0d |
| IRI10 |  | CONCRETO (f´c = 21 MPa) | 2d | 2022-12-21 | 2022-12-22 | IRI05 | 181d |  |
| IRI02 |  | CONFORMACIÓN Y COMPACTACIÓN PARA ESTRUCTURA | 3d | 2022-12-24 | 2022-12-26 | IRI01 FF | 130d | 0d |
| IRI07 |  | CONCRETO PREMEZCLADO (f´c = 10 MPa) PARA SOLADO | 2d | 2022-12-27 | 2022-12-28 | IRI02 | 130d | 0d |
| IRI15 |  | TUBERÍA HDPE 600 mm (SUMINISTRO E INSTALACIÓN) | 1d | 2022-12-27 | 2022-12-27 | IRI01 | 137d | 0d |
| IRI16 |  | TUBERÍA HDPE 750 mm (SUMINISTRO E INSTALACIÓN) | 2d | 2022-12-28 | 2022-12-29 | IRI15 | 137d | 0d |
| IRI12 |  | ACERO DE REFUERZO P/ESTRUCTURAS (fý= 420 Mpa) | 27d | 2022-12-29 | 2023-01-24 | IRI07 | 130d | 0d |
| IRI13 |  | ENCOFRADO PLANO | 34d | 2022-12-29 | 2023-01-31 | IRI12 SS | 130d | 0d |
| IRI17 |  | TUBERÍA HDPE 900 mm (SUMINISTRO E INSTALACIÓN) | 3d | 2022-12-30 | 2023-01-01 | IRI16 | 137d | 0d |
| IRI18 |  | TUBERÍA HDPE 1000 mm (SUMINISTRO E INSTALACIÓN) | 2d | 2023-01-02 | 2023-01-03 | IRI17 | 137d | 7d |
| IRI11 |  | CONCRETO (f'c = 28 MPa) EN MUROS Y ZAPATAS | 25d | 2023-01-11 | 2023-02-04 | IRI14 FF, IRI18 | 130d | 0d |
| IRI27 |  | IMPERMEABILIZACIÓN DE PARÁMETROS ENTERRADOS CON LÁMINA ASFÁLTICA | 14d | 2023-01-22 | 2023-02-04 | IRI11 FF | 133d | 0d |
| IRI25 |  | JUNTA DE DILATACIÓN ASFÁLTICA | 14d | 2023-01-24 | 2023-02-06 | IRI24 FF | 135d | 0d |
| IRI08 |  | CONCRETO CICLOPEO (f'c = 14 Mpa+30% PM) | 5d | 2023-01-25 | 2023-01-29 | IRI06 | 143d |  |
| IRI09 |  | CONCRETO (f'c = 14 Mpa) | 11d | 2023-01-25 | 2023-02-04 | IRI06 | 137d |  |
| IRI14 |  | ENCOFRADO CURVO | 4d | 2023-02-01 | 2023-02-04 | IRI13 | 130d | 0d |
| IRI23 |  | BARANDA METÁLICA (INCLUYE SUMINSTRO E INSTALACIÓN) | 1d | 2023-02-04 | 2023-02-04 | IRI11 FF | 137d |  |
| IRI04 |  | RELLENO CON MATERIAL PROPIO | 4d | 2023-02-05 | 2023-02-08 | IRI27 | 133d |  |
| IRI19 |  | COMPUERTA TIPO ARMCO 0.60 m x 0.60 m (INCLUYE SUMINISTRO E INSTALACIÓN) | 2d | 2023-02-05 | 2023-02-06 | IRI11 | 130d | 0d |
| IRI22 |  | REJILLA METÁLICA PARA ELEMENTO DE PROTECCION DE INTERFERENCIAS HIDRAULICAS | 3d | 2023-02-05 | 2023-02-07 | IRI11 | 134d |  |
| IRI24 |  | JUNTA DE ESTANQUEIDAD WATERSTOP | 2d | 2023-02-05 | 2023-02-06 | IRI11 | 135d | 0d |
| IRI26 |  | JUNTA WATERSTOP DE PVC 8" | 2d | 2023-02-05 | 2023-02-06 | IRI25 FF | 135d |  |
| IRI31 |  | COMPUERTA ANTIRETORNO TIPO CLAPETA D=0.90 m (SUMINISTRO Y ALIMENTACION) | 7d | 2023-02-05 | 2023-02-11 | IRI21 FF | 130d |  |
| IRI20 |  | COMPUERTA TIPO ARMCO 0.75 m x 0.75 m (INCLUYE SUMINISTRO E INSTALACIÓN) | 3d | 2023-02-07 | 2023-02-09 | IRI19 | 130d | 0d |
| IRI21 |  | COMPUERTA TIPO ARMCO 1.00 m x 1.00 m (INCLUYE SUMINISTRO E INSTALACIÓN) | 2d | 2023-02-10 | 2023-02-11 | IRI20 | 130d | 0d |

| ID | WBS | Activity | Duration | Start | Finish | Predecessors | Total float | Free float |
| --- | --- | --- | --- | --- | --- | --- | --- | --- |
|  | C3 | **OBRAS DE REDES** |  | 2022-12-11 | 2023-01-24 |  |  |  |
| IRE01 |  | REUBICACIÓN DE POSTE DE ENERGÍA | 45d | 2022-12-11 | 2023-01-24 | PRE02 | 38d |  |
| IRE02 |  | REUBICACIÓN DE POSTE DE TELEFONÍA | 45d | 2022-12-11 | 2023-01-24 | PRE02 | 38d |  |
|  | C4 | **CRUCE VIAL** |  | 2022-12-11 | 2023-03-27 |  |  |  |
| IVI01 |  | DESBROCE Y LIMPIEZA | 4d | 2022-12-11 | 2022-12-14 | PRE02 | 0d |  |
| IVI02 |  | EXCAVACIÓN MASIVA EN MATERIAL SUELTO, CON EQUIPO | 17d | 2022-12-15 | 2022-12-31 | IVI01 | 0d |  |
| IVI03 |  | EXCAVACIÓN EN ROCA SUELTA CON EQUIPO | 1d | 2023-01-01 | 2023-01-01 | IVI02 | 0d |  |
| IVI04 |  | EXCAVACION DE ROCA FIJA CON MARTILLO HIDRÁULICO | 5d | 2023-01-02 | 2023-01-06 | IVI03 | 0d |  |
| IVI05 |  | EXCAVACION DE UÑA EN MATERIAL CON NIVEL FREATICO | 12d | 2023-01-07 | 2023-01-18 | IVI04 | 0d |  |
| IVI06 |  | CONFORMACIÓN Y COMPACTACIÓN DE DIQUE | 40d | 2023-01-19 | 2023-02-27 | IVI05 | 0d |  |
| IVI15 |  | CONCRETO (f'c = 28 MPa) EN MUROS Y ZAPATAS | 60d | 2023-01-26 | 2023-03-26 | IVI13 FF | 0d |  |
| IVI07 |  | ENROCADO Y ACOMODO DE ROCA PARA PROTECCIÓN DE TALUD TIPO 1 | 18d | 2023-02-10 | 2023-02-27 | IVI06 FF | 0d |  |
| IVI08 |  | ENROCADO Y ACOMODO DE ROCA EN UÑA ANTISOCAVANTE TIPO 1 | 17d | 2023-02-11 | 2023-02-27 | IVI06 FF | 114d | 0d |
| IVI10 |  | GEOTEXTIL NO TEJIDO CLASE 2, INCLUYE INSTALACIÓN | 1d | 2023-02-11 | 2023-02-11 | IVI08 SS | 130d |  |
| IVI11 |  | RELLENO COMPACTADO CON MATERIAL PARA AFIRMADO EN CORONA | 10d | 2023-02-28 | 2023-03-09 | IVI07 | 0d |  |
| IVI12 |  | RELLENO CON MATERIAL PROPIO | 4d | 2023-03-06 | 2023-03-09 | IVI11 FF | 0d |  |
| IVI13 |  | GEOCELDA HORMIGONADA | 17d | 2023-03-10 | 2023-03-26 | IVI12 | 0d |  |
| IVI14 |  | RELLENO COMPACTADO | 1d | 2023-03-27 | 2023-03-27 | IVI15 | 86d |  |
|  | C5 | **OBRAS DE CONCRETO EXISTENTE** |  | 2022-12-11 | 2023-01-02 |  |  |  |
| ICE01 |  | DEMOLICION DE OBRA DE CONCRETO EXISTENTE | 23d | 2022-12-11 | 2023-01-02 | PRE02 | 165d | 0d |
|  | 900 | **TRABAJOS DE CIERRE** |  | 2022-12-11 | 2023-06-03 |  |  |  |
| CIE01 |  | MEDIDAS DE MANEJO AMBIENTAL | 160d | 2022-12-11 | 2023-05-19 | PROV02 | 33d |  |
| CIE02 |  | MEDIDAS DE MANEJO DE RESIDUOS SÓLIDOS | 160d | 2022-12-11 | 2023-05-19 | PROV02 | 33d |  |
| CIE03 |  | MONITOREO DE CALIDAD AIRE | 160d | 2022-12-11 | 2023-05-19 | PROV02 | 33d |  |
| CIE04 |  | MONITOREO DE CALIDAD RUIDO | 160d | 2022-12-11 | 2023-05-19 | PROV02 | 33d |  |
| CIE05 |  | MONITOREO DE CALIDAD AGUA | 160d | 2022-12-11 | 2023-05-19 | PROV02 | 33d |  |
| CIE06 |  | MONITOREO DE CALIDAD SUELO | 160d | 2022-12-11 | 2023-05-19 | PROV02 | 18d | 0d |
| CIE07 |  | MEDIDAS DE CONTINGENCIAS Y CIERRE DE OBRA | 15d | 2023-05-20 | 2023-06-03 | CIE06 | 18d |  |

| ID | WBS | Activity | Duration | Start | Finish | Predecessors | Total float | Free float |
| --- | --- | --- | --- | --- | --- | --- | --- | --- |
|  | 700 | **OBRAS COMPLEMENTARIAS** |  | 2023-01-03 | 2023-01-07 |  |  |  |
| COM01 |  | EMBOQUILLADO DE PIEDRA CON CONCRETO | 5d | 2023-01-03 | 2023-01-07 | ICE01 | 165d |  |
|  | C | **INFRAESTRUCTURA VERDE Y PAISAJISMO** |  | 2023-05-03 | 2023-06-21 |  |  |  |
|  | 1000 | **INFRAESTRUCTURA VERDE Y PAISAJISMO** |  | 2023-05-03 | 2023-06-21 |  |  |  |
| PAI01 |  | REPOSICION DE HUARO | 12d | 2023-05-03 | 2023-05-14 | MTE12 | 0d |  |
| PAI11 |  | BANCAS DE MADERA SOBRE GAVIÓN TIPO T2 | 2d | 2023-05-03 | 2023-05-04 | MTE12 | 39d | 0d |
| PAI16 |  | JUEGO INFANTIL SUBE Y BAJA TRIPLE DE ESTRUCTURA DE TUBOS DE ACERO PINTADOS (INCLUYE CIMENTACIÓN) | 2d | 2023-05-03 | 2023-05-04 | PAI01 SS | 14d | 0d |
| PAI33 |  | TRANSPLANTE DE ARBOL ADULTO H> 2.50M CON MEDIO MECÁNICO. INCLUYE CAPADO DE RAICES) | 7d | 2023-05-03 | 2023-05-09 | PAI16 SS | 14d | 0d |
| PAI12 |  | PAPELERAS DE RECICLAJE DE ACABADO DE MADERA EN ESTRUCTURA DE 4 (75 LITROS C/U) | 1d | 2023-05-05 | 2023-05-05 | PAI11 | 39d | 0d |
| PAI17 |  | COLUMPIO TRIPLE DE ESTRUCTURA CON TUBOS DE ACERO PINTADOS (INCLUYE CIMENTACIÓN) | 2d | 2023-05-05 | 2023-05-06 | PAI16 | 16d | 0d |
| PAI13 |  | BANCAS CIRCULARES DE MADERA CON RESPALDAR SOBRE BASE DE CONCRETO. TIPO T3 | 3d | 2023-05-06 | 2023-05-08 | PAI12 | 39d | 0d |
| PAI18 |  | JUEGO INFANTIL RUEDA GIRATORIA CON BARANDALES DE DIMENSIONES ø1.85X1.00 M | 2d | 2023-05-07 | 2023-05-08 | PAI17 | 16d | 0d |
| PAI14 |  | BANCA CORRIDA DE MADERA SOBRE BASE DE CONCRETO. T4 | 5d | 2023-05-09 | 2023-05-13 | PAI13 | 39d |  |
| PAI19 |  | JUEGO INFANTIL DE PASAMANOS RECTO CON ACERO PINTADO. DIMENSIONES 2.05X0.55X2.03 M | 2d | 2023-05-09 | 2023-05-10 | PAI18 | 16d | 0d |
| PAI34 |  | TALA DE ARBOL CON MEDIO MECÁNICO | 8d | 2023-05-10 | 2023-05-17 | PAI33 | 14d | 0d |
| PAI20 |  | JUEGO DE TREPAR DOMO DE MADERA. DIMENSIONES ø3.80 M, H=1.90 M | 2d | 2023-05-11 | 2023-05-12 | PAI19 | 16d | 0d |
| PAI21 |  | CALISTENIA ELÍPTICA | 2d | 2023-05-13 | 2023-05-14 | PAI20 | 16d | 0d |
| PAI02 |  | DEMOLICION Y ELIMINACION DE CONSTRUCCIOES PRECARIAS EXISTENTES | 7d | 2023-05-15 | 2023-05-21 | PAI01 | 0d |  |
| PAI22 |  | CALISTENIA BANCA PARA ABDOMINALES | 2d | 2023-05-15 | 2023-05-16 | PAI21 | 16d | 0d |
| PAI23 |  | CALISTENIA BARRA DOBLE | 2d | 2023-05-17 | 2023-05-18 | PAI22 | 16d | 0d |
| PAI35 |  | TRASPLANTE DE ÁRBOL JUVENIL O ALTURA H=2.50M CON MEDIOS MANUALES (INCLUYE CAPADO DE RAÍCES) | 1d | 2023-05-18 | 2023-05-18 | PAI34 | 14d | 0d |
| PAI24 |  | CALISTENIA MIXTA. APARATO TIPO ELÍPTICA+VOLANTE | 2d | 2023-05-19 | 2023-05-20 | PAI23 | 16d | 0d |
| PAI36 |  | AJUSTE DE COTA DE ÁRBOL ADULTO O ALTURA H=2.50M CON MEDIOS MECÁNICOS (INCLUYE CAPADO DE RAÍCES) | 5d | 2023-05-19 | 2023-05-23 | PAI35 | 14d | 0d |
| PAI25 |  | PAR DE BOLARDOS FIJOS DE CONCRETO H=0.60 Y ø25 CM, ACABADO RÚSTICO CON CADENA DE FIERRO PINTADO | 2d | 2023-05-21 | 2023-05-22 | PAI24 | 16d | 0d |
| PAI03 |  | LIMPIEZA Y DESBROCE DEL TERRENO CON MEDIOS MANUALES | 1d | 2023-05-22 | 2023-05-22 | PAI02 | 0d |  |
| PAI04 |  | DESPEDREGADO DEL TERRENO CON MEDIOS MANUALES | 1d | 2023-05-23 | 2023-05-23 | PAI03 | 0d |  |
| PAI06 |  | SARDINELES DE CONCRETO A NIVEL DE PISO DE ALTURA H=20 CM ESPESOR E=15 CM | 15d | 2023-05-23 | 2023-06-06 | PAI05 FF | 1d | 0d |
| PAI26 |  | BICICLETERO DE ACERO PINTADO (INCLUYE CIMENTACIÓN) | 2d | 2023-05-23 | 2023-05-24 | PAI25 | 16d | 0d |
| PAI05 |  | REMOCIÓN DEL TERRENO CON MEDIOS MANUALES CON PROFUNDIDAD HASTA 25CM | 14d | 2023-05-24 | 2023-06-06 | PAI04 | 0d |  |
| PAI38 |  | ADAPTACIÓN DE TERRENO ENTORNO A ÁRBOL EXISTENTE A MANTENER EN SU SITIO | 1d | 2023-05-24 | 2023-05-24 | PAI36 | 14d | 13d |
| PAI27 |  | PIEDRA ORNAMENTAL PARA PARQUES DE DIMENSIONES APROX 60-100 CM | 2d | 2023-05-25 | 2023-05-26 | PAI26 | 16d | 0d |
| PAI28 |  | CONTENEDOR DE COMPOSTAJE DE DIMENSIONES 0.50X0.50M Y H=60CM | 2d | 2023-05-27 | 2023-05-28 | PAI27 | 16d | 0d |
| PAI29 |  | PANEL INFORMATIVO H=1.55 M. TIPO C | 2d | 2023-05-29 | 2023-05-30 | PAI28 | 16d | 0d |
| PAI30 |  | SEÑALÉTICA INFORMATIVA DE ESPECIES DE H=60 CM. TIPO D | 2d | 2023-05-31 | 2023-06-01 | PAI29 | 16d | 0d |
| PAI31 |  | CONFORMACIÓN Y COMPACTACIÓN DE BASE GRANULAR DE ESPESOR e=0.15m (INCLUYE MATERIAL) | 2d | 2023-06-02 | 2023-06-03 | PAI30 | 16d | 0d |
| PAI32 |  | CAPA SUPERFICIAL DE ARENA DE ESPESOR e=0.05m | 2d | 2023-06-04 | 2023-06-05 | PAI31 | 16d |  |
| PAI07 |  | SARDINELES DE CONCRETO DE ALTURA H=15 CM SOBRE EL NIVEL DE PISO Y ALTURA TOTAL=40 CM ESPESOR E=15 CM | 14d | 2023-06-07 | 2023-06-20 | PAI06 | 1d |  |
| PAI08 |  | SUELO DE ARENA PARA ZONA LÚDICA | 5d | 2023-06-07 | 2023-06-11 | PAI05 | 0d |  |
| PAI39 |  | MÓDULO DE INFORMACIÓN MADERA TRATADA S/ LOSA CONCRETO E=10 CM, 2.00X5.00 M, H=3.05 M C. INCLINADA | 4d | 2023-06-07 | 2023-06-10 | PAI05, PAI38 | 1d | 0d |
| PAI40 |  | CERCO PERIMETRAL DE ALAMBRE H=2.00 M PARA ZONA DE HUERTO | 7d | 2023-06-11 | 2023-06-17 | PAI39 | 1d | 0d |
| PAI09 |  | PISO DE EMPEDRADO FRAGUADO EN PLAZAS | 5d | 2023-06-12 | 2023-06-16 | PAI08 | 0d |  |
| PAI10 |  | JUNTAS DE CONSTRUCCIÓN DE ESPESOR 1/2" | 5d | 2023-06-17 | 2023-06-21 | PAI09, PAI07 FF | 0d |  |
| PAI41 |  | PUERTA DE DOS HOJAS CON ESTRUCTURA DE MADERA DE DIMENSIONES TOTALES 2.00X1.50 M EN CERCO | 1d | 2023-06-18 | 2023-06-18 | PAI40 | 1d | 0d |
| PAI42 |  | BORDE DE MADERA PARA SEPARACIÓN DE PARCELAS EN ZONA DE HUERTO | 2d | 2023-06-19 | 2023-06-20 | PAI41 | 1d |  |

| ID | WBS | Activity | Type | Duration | Start | Finish | Predecessors | Total float | Free float |
| --- | --- | --- | --- | --- | --- | --- | --- | --- | --- |
|  | 1200 | **ESTRUCTURAS** |  |  | 2023-05-18 | 2023-06-21 |  |  |  |
| EST01 |  | EXCAVACIÓN EN MATERIAL SUELTO, CON EQUIPO |  | 1d | 2023-05-18 | 2023-05-18 | MTE11 | 10d | 0d |
| EST02 |  | CONFORMACIÓN Y COMPACTACIÓN PARA ESTRUCTURA |  | 1d | 2023-05-19 | 2023-05-19 | EST01 | 10d | 0d |
| EST03 |  | CONCRETO CICLOPEO (f'c=14MPa + 30% PM) |  | 1d | 2023-05-20 | 2023-05-20 | EST02 | 10d | 0d |
| EST05 |  | ACERO DE REFUERZO P/ESTRUCTURAS (fý= 420 Mpa) |  | 15d | 2023-05-21 | 2023-06-04 | EST06 FF | 10d | 0d |
| EST06 |  | ENCOFRADO PLANO |  | 15d | 2023-05-21 | 2023-06-04 | EST03 | 10d | 0d |
| EST04 |  | CONCRETO PREMEZCLADO PARA ESTRUCTURAS (f´c = 21 MPa) |  | 7d | 2023-06-05 | 2023-06-11 | EST05 | 10d |  |
| CRC.D |  | FIN | milestone | 0d | 2023-06-21 | 2023-06-21 | PRE06, EST04, CIE07, PRE03, PAI42, PAI32, PAI14, CIE01, CIE02, CIE03, CIE04, CIE05, CIE06, PAI10, TRA04, TRA06, TRA08, TRA11, TRA12, MTE14, MTN17, MTN08, IRI03, IRI04, IRI08, IRI09, COM01 | 0d |  |
